# Projektavimas

Schedule from MS Project, 2022-10-14 to 2023-06-14.

## Calendars

- Standard: Mon-Fri 08:00-12:00, 13:00-17:00; Sat-Sun off. Exceptions (off unless hours are given): 2013-01-01 to 2030-01-01 (Naujieji metai, recurring), 2013-02-16 to 2030-02-16 (Valstybės atkurimo diena, recurring), 2013-03-11 to 2030-03-11 (Nepriklausomybes atkurimo diena, recurring), 2013-05-01 to 2030-05-01 (Tarptautine darbininku diena, recurring), 2013-06-24 to 2030-06-24 (Jonines (Rasos), recurring), 2013-07-06 to 2030-07-06 (Valstybes (Lietuvos karaliaus Mindaugo karunavimo) diena, recurring), 2013-08-15 to 2030-08-15 (Zoline, Sv. Mergeles Marijos dangun emimo svente, recurring), 2013-11-01 to 2030-11-01 (Visu sventuju diena, recurring), 2013-12-24 to 2030-12-24 (Sv. Kucios, recurring), 2013-12-25 to 2030-12-25 (Sv. Kaledos, recurring), 2013-12-26 to 2030-12-26 (Sv. Kaledos (antroji diena), recurring), 2019-06-20 to 2024-04-02 07:30-11:30, 12:15-16:30 (Darbo diena (I-IV) 07:30-16:30, recurring), 2019-06-21 to 2030-12-27 07:30-11:30, 12:15-15:15 (Darbo diena (V) 07:30-15:15, recurring), 2023-04-10 (Sv. Velykos (antroji diena)).

## Resources

| Resource | Rate |
| --- | --- |
| Rangovas |  |
| Litgrid AB |  |
| Ekspertizės rangovas |  |
| Infostatyba |  |
| PV |  |
| ESO |  |
| _ITTAD ITTC TIG vyresnysis inžinierius | 17.8 |
| _ITTAD ITTC DPG PVS administratorius | 17.8 |
| _ITTAD ITTC VSG DVS administratorius | 17.8 |
| _ITTAD ITTC DPG duomenų tinklo administratorius (KR) | 17.8 |
| _ITTAD ITTC DPG duomenų tinklo administratorius (IP) | 17.8 |

## Schedule

| ID | WBS | Task | Type | Duration | Start | Finish | Predecessors | Baseline start | Baseline finish | Baseline duration | Total slack | Free slack | Constraint | Resources | Work |
| --- | --- | --- | --- | --- | --- | --- | --- | --- | --- | --- | --- | --- | --- | --- | --- |
| 1 | 1 | **I ETAPAS. PROJEKTAVIMAS** |  | 167.84d | 2022-10-14 | 2023-06-14 |  | 2019-12-18 | 2020-08-18 | 166d | 0d |  |  |  | 1864h |
| 2 | 1.1 | Topo nuotraukos užsakymas ir suderinimas |  | 30d | 2022-10-14 | 2022-11-28 |  |  |  |  | 138.84d |  | start no earlier than 2022-10-14 | Rangovas | 240h |
| 3 | 1.2 | Pateikti geologinių tyrinėjimų vietas susiderinimui |  | 5d | 2022-11-16 | 2022-11-23 |  |  |  |  | 101.94d | 0d | start no earlier than 2022-11-16 | Rangovas | 40h |
| 4 | 1.3 | Atlikti inžineriniai geodeziniai tyrinėjimai ir pateika įregistravimo pažyma |  | 40d | 2022-11-23 | 2023-01-19 | 3 | 2019-12-18 | 2020-01-14 | 16d | 101.94d |  |  | Rangovas | 320h |
| 5 | 1.4 | **Techninis projektas** |  | 138d | 2022-11-28 | 2023-06-14 |  | 2019-12-18 | 2020-07-10 | 139d | 0d |  |  |  | 1264h |
| 6 | 1.4.1 | Techninio projekto rengimas |  | 40d | 2022-11-28 | 2023-01-24 |  | 2020-01-28 | 2020-02-26 | 22d | 0d |  | start no earlier than 2022-11-28 | Rangovas | 320h |
| 7 | 1.4.2 | Pakoreguoti ir pateikti techninį projektą 1 peržiūrai |  | 1d | 2023-01-24 | 2023-01-25 | 6 | 2020-02-26 | 2020-02-26 | 0d | 0d |  |  | Rangovas | 8h |
| 8 | 1.4.3 | Pateikti pastabas po 1 peržiūros |  | 20d | 2023-01-25 | 2023-02-23 | 7 | 2020-02-27 | 2020-03-17 | 13d | 0d |  |  | Litgrid AB | 160h |
| 9 | 1.4.4 | Pakoreguoti ir pateikti techninį projektą 2 peržiūrai |  | 10d | 2023-02-23 | 2023-03-09 | 8 | 2020-03-18 | 2020-04-03 | 13d | 0d |  |  | Rangovas | 80h |
| 10 | 1.4.5 | Pateikti pastabas po 2 peržiūros |  | 5d | 2023-03-09 | 2023-03-16 | 9 | 2020-04-06 | 2020-04-20 | 10d | 0d |  |  | Litgrid AB | 40h |
| 11 | 1.4.6 | Pakoreguoti ir pateikti techninį projektą 3 peržiūrai |  | 9d | 2023-03-16 | 2023-03-29 | 10 | 2020-04-21 | 2020-05-04 | 9d | 0d |  |  | Rangovas | 72h |
| 12 | 1.4.7 | Pateikti pastabas/suderinti po 3 peržiūros |  | 5d | 2023-03-29 | 2023-04-05 | 11 | 2020-05-05 | 2020-05-18 | 10d | 0d |  |  | Litgrid AB | 40h |
| 13 | 1.4.8 | Techninis projektas suderintas | milestone | 0d | 2023-04-05 | 2023-04-05 | 12 |  |  |  | 0d |  |  | Litgrid AB |  |
| 14 | 1.4.9 | **Techninio projekto bendroji ekspertizė** |  | 21d | 2023-04-05 | 2023-05-08 |  | 2020-04-21 | 2020-07-10 | 56d | 0d |  |  |  | 328h |
| 15 | 1.4.9.1 | Techninio projekto bendroji ekspertizė |  | 20d | 2023-04-05 | 2023-05-05 | 13 | 2020-04-21 | 2020-04-21 | 1d | 0d |  |  | Ekspertizės rangovas; Litgrid AB | 320h |
| 16 | 1.4.9.2 | Pateikta ekspertizės teigiama išvada projektui |  | 1d | 2023-05-05 | 2023-05-08 | 15 | 2020-06-26 | 2020-07-09 | 9d | 0d |  |  | Ekspertizės rangovas | 8h |
| 17 | 1.4.9.3 | Pateiktas aktas apie projekto patvirtinimą | milestone | 0d | 2023-05-08 | 2023-05-08 | 16 | 2020-07-10 | 2020-07-10 | 1d | 0d |  |  | Litgrid AB |  |
| 18 | 1.4.10 | **Statybą leidžiantis dokumentas** |  | 27d | 2023-05-08 | 2023-06-14 |  | 2020-07-13 | 2020-08-18 | 27d | 0d |  |  |  | 216h |
| 19 | 1.4.10.1 | Techninis projektas pateiktas į Infostatybą su visais reikiamais dokumentais |  | 1d | 2023-05-08 | 2023-05-09 | 17 | 2020-07-13 | 2020-07-13 | 1d | 0d |  |  | Rangovas | 8h |
| 20 | 1.4.10.2 | Patikrinta pateiktos dokumentacijos sudėtis |  | 3d | 2023-05-09 | 2023-05-12 | 19 | 2020-07-14 | 2020-07-16 | 3d | 0d |  |  | Infostatyba | 24h |
| 21 | 1.4.10.3 | Suinteresuotos organizacijos patikrino pateiktą dokumentaciją |  | 20d | 2023-05-12 | 2023-06-09 | 20 | 2020-07-17 | 2020-08-13 | 20d | 0d |  |  | Infostatyba | 160h |
| 22 | 1.4.10.4 | Išduotas statybos leidimas |  | 3d | 2023-06-09 | 2023-06-14 | 21 | 2020-08-14 | 2020-08-18 | 3d | 0d |  |  | Infostatyba | 24h |
| 23 | 1.4.10.5 | Gautas statybą leidžiantis dokumentas | milestone | 0d | 2023-06-14 | 2023-06-14 | 22 | 2020-08-18 | 2020-08-18 | 0d | 0d |  |  | Rangovas |  |
